# Home Construction

Schedule from Primavera P6, 2015-10-13 to 2016-01-08, data date 2015-10-13, costs in USD.

## Calendars

- Calendar 1: Mon off; Tue-Sat 09:00-14:00, 15:00-19:00; Sun off.

## Resources

| Resource | Group | Rate |
| --- | --- | --- |
| Daniel Muller | labor | 55 |
| Land Surveyor | labor | 65 |

## Schedule

| ID | WBS | Activity | Type | Duration | Start | Finish | Predecessors | Planned start | Planned finish | Total float | Free float | Resources | Cost |
| --- | --- | --- | --- | --- | --- | --- | --- | --- | --- | --- | --- | --- | --- |
| A1000 |  | Project Start | milestone | 0d | 2015-10-13 | 2015-10-13 |  |  |  | 61d | 0d |  |  |
| A1010 |  | Project Management | level of effort | 72d | 2015-10-13 | 2016-01-07 | A1000 SS | 2015-10-13 | 2016-01-08 | 1d | 0d | Daniel Muller [4608 h] | 253,440 |
| A1020 |  | Project Complete | milestone | 0d | 2016-01-07 | 2016-01-07 | A1010 FF, A1170 FF, A1190, A1230 FF, A1260 FF |  |  | 1d |  |  |  |
|  | 1 | **Grading** |  |  | 2015-10-13 | 2015-10-23 |  |  |  |  |  |  |  |
| A1030 |  | Survey and mark out site |  | 3d | 2015-10-13 | 2015-10-15 | A1000 SS |  |  | 61d | 0d | Land Surveyor [192 h] | 12,480 |
| A1040 |  | Site Demarcation |  | 1d | 2015-10-15 | 2015-10-16 | A1030 |  |  | 61d | 0d |  |  |
| A1050 |  | Excavation | resource dependent | 3d | 2015-10-17 | 2015-10-22 | A1040 FS+1d |  |  | 61d | 0d |  |  |
| A1060 |  | Grade Site |  | 2d | 2015-10-22 | 2015-10-23 | A1050 |  |  | 61d |  |  |  |
|  | 2 | **Foundation** |  |  | 2015-10-13 | 2015-10-28 |  |  |  |  |  |  |  |
| A1070 |  | Laying of Foundation |  | 4d | 2015-10-13 | 2015-10-16 |  |  |  | 0d |  |  |  |
| A1080 |  | Slab Plumbing |  | 7d | 2015-10-16 | 2015-10-24 | A1070 |  |  | 0d |  |  |  |
| A1090 |  | Pour and Float slab concrete |  | 2d | 2015-10-24 | 2015-10-28 | A1080 |  |  | 0d |  |  |  |
|  | 3 | **Structure** |  |  | 2015-10-13 | 2016-01-08 |  |  |  |  |  |  |  |
|  | 1 | **Framing** |  |  | 2015-11-05 | 2016-01-07 |  |  |  |  |  |  |  |
| A1100 |  | Exterior Walls |  | 20d | 2015-11-05 | 2015-12-01 | A1090 FS+7d |  |  | 0d |  |  |  |
| A1120 |  | Exterior Cladding |  | 30d | 2015-12-01 | 2016-01-07 | A1100 |  |  | 1d |  |  |  |
| A1110 |  | Interior Walls |  | 25d | 2015-12-04 | 2016-01-05 | A1100 FS+3d |  |  | 3d |  |  |  |
|  | 2 | **Roof** |  |  | 2015-12-01 | 2016-01-05 |  |  |  |  |  |  |  |
| A1130 |  | Truss Placing |  | 15d | 2015-12-01 | 2015-12-18 | A1100 |  |  | 0d |  |  |  |
| A1140 |  | Roof Sheeting |  | 10d | 2015-12-18 | 2015-12-31 | A1130 |  |  | 0d |  |  |  |
| A1150 |  | Place Paper and Shingles |  | 3d | 2015-12-31 | 2016-01-05 | A1140 |  |  | 0d |  |  |  |
|  | 3 | **Interior** |  |  | 2015-10-13 | 2016-01-08 |  |  |  |  |  |  |  |
|  | 1 | **Mechanical** |  |  | 2016-01-05 | 2016-01-08 |  |  |  |  |  |  |  |
| A1160 |  | HVAC Ducting |  | 3d | 2016-01-05 | 2016-01-08 | A1150 |  |  | 0d |  |  |  |
| A1170 |  | Install HVAC Unit |  | 2d | 2016-01-05 | 2016-01-07 | A1160 SS |  |  | 1d | 0d |  |  |

| ID | WBS | Activity | Duration | Start | Finish | Predecessors | Total float | Free float |
| --- | --- | --- | --- | --- | --- | --- | --- | --- |
|  | 2 | **Electrical** |  | 2015-12-01 | 2015-12-16 |  |  |  |
| A1180 |  | Breaker Box and Rough Wire | 5d | 2015-12-01 | 2015-12-05 | A1100 | 19d | 0d |
| A1190 |  | Finish Wiring | 7d | 2015-12-08 | 2015-12-16 | A1180 | 19d | 18d |
|  | 3 | **Plumbing** |  | 2015-12-01 | 2015-12-12 |  |  |  |
| A1200 |  | Install Rough Plumbing lines | 10d | 2015-12-01 | 2015-12-12 | A1100 | 7d | 0d |
|  | 4 | **Decor** |  | 2015-10-13 | 2015-12-30 |  |  |  |
| A1230 |  | Kitchen Cabinets | 10d | 2015-10-13 | 2015-10-23 |  | 61d | 60d |
| A1210 |  | Placing Doors | 8d | 2015-12-12 | 2015-12-23 | A1200 | 7d | 0d |
| A1220 |  | Door Casings and Baseboards | 6d | 2015-12-23 | 2015-12-30 | A1210 | 7d |  |
|  | 4 | **Exterior** |  | 2015-10-13 | 2015-11-03 |  |  |  |
| A1240 |  | Place Window | 12d | 2015-10-13 | 2015-10-27 |  | 49d | 0d |
| A1250 |  | Window Sidings | 5d | 2015-10-27 | 2015-11-03 | A1240 | 49d | 0d |
|  | 5 | **Landscaping** |  | 2015-11-03 | 2015-11-07 |  |  |  |
| A1260 |  | Tree Plantings | 5d | 2015-11-03 | 2015-11-07 | A1250 | 49d | 48d |
